# ejemplo1

Schedule from MS Project, 2005-11-02 to 2006-02-09.
Telefónica CTC Chile

## Calendars

- Estándar: Mon-Fri 09:00-13:00, 15:00-19:00; Sat-Sun off.

## Resources

| Resource |
| --- |
| instalador |
| ingeniero |

## Schedule

| ID | Task | Duration | Start | Finish | Predecessors | Total slack | Free slack | Constraint |
| --- | --- | --- | --- | --- | --- | --- | --- | --- |
| 1 | Apertura de presupuesto específico | 1d | 2005-11-02 | 2005-11-02 |  | 0d |  |  |
| 2 | Elaboración del proyecto de ingeniería | 10d | 2005-11-03 | 2005-11-16 | 1 | 0d |  | finish no earlier than 2005-11-02 |
| 3 | Aprobación del proyecto de ingeniería | 5d | 2005-11-17 | 2005-11-23 | 2 | 0d |  | finish no earlier than 2005-11-02 |
| 4 | Emisión de ordenes de compra | 3d | 2005-11-24 | 2005-11-28 | 3 | 5d | 0d | finish no earlier than 2005-11-02 |
| 5 | Emisión de ordenes de trabajo | 3d | 2005-11-24 | 2005-11-28 | 3 | 0d |  | finish no earlier than 2005-11-02 |
| 6 | Compra de equipos | 5d | 2005-11-29 | 2005-12-05 | 4 | 20d |  | finish no earlier than 2005-11-02 |
| 7 | Compra de materiales | 5d | 2005-11-29 | 2005-12-05 | 4 | 5d |  | finish no earlier than 2005-11-02 |
| 8 | Contratación de mano de obra | 10d | 2005-11-29 | 2005-12-12 | 5 | 0d |  | finish no earlier than 2005-11-02 |
| 9 | Obras civiles | 15d | 2005-12-13 | 2006-01-02 | 7, 8 | 0d |  | finish no earlier than 2005-11-02 |
| 10 | Instalación y habilitación de energía | 4d | 2006-01-03 | 2006-01-06 | 9, 6 | 0d |  | finish no earlier than 2005-11-02 |
| 11 | Instalación de accesos y enlaces | 3d | 2006-01-09 | 2006-01-11 | 10 | 0d |  | finish no earlier than 2005-11-02 |
| 12 | Instalación de equipos | 3d | 2006-01-09 | 2006-01-11 | 10 | 0d |  | finish no earlier than 2005-11-02 |
| 13 | Pruebas de sistemas | 1d | 2006-01-12 | 2006-01-12 | 11, 12 | 0d |  | finish no earlier than 2005-11-02 |
| 14 | Instalación de equipos terminales | 10d | 2006-01-13 | 2006-01-26 | 13 | 0d |  | finish no earlier than 2005-11-02 |
| 15 | Pruebas y entrega de equipos terminales | 3d | 2006-01-27 | 2006-01-31 | 14 | 0d |  | finish no earlier than 2005-11-02 |
| 16 | Procesamiento de facturas de proveedores | 5d | 2006-02-01 | 2006-02-07 | 15 | 0d |  | finish no earlier than 2005-11-02 |
| 17 | Emisión de informe final | 1d | 2006-02-08 | 2006-02-08 | 16 | 0d |  | finish no earlier than 2005-11-02 |
| 18 | Cierre de presupuesto específico | 1d | 2006-02-09 | 2006-02-09 | 17 | 0d |  | finish no earlier than 2005-11-02 |
